# Software Development

Schedule from MS Project, 2010-11-01 to 2011-04-26.

## Calendars

- Standard: Mon-Fri 08:00-12:00, 13:00-17:00; Sat-Sun off.

## Resources

| Resource |
| --- |
| Management |
| Project Manager |
| Analyst |
| Developer |
| Testers |
| Trainers |
| Technical Communicators |
| Deployment Team |

## Schedule

| ID | WBS | Task | Type | Duration | Start | Finish | Predecessors | Total slack | Constraint | Resources | Work |
| --- | --- | --- | --- | --- | --- | --- | --- | --- | --- | --- | --- |
| 1 | 1 | **Yazılım Geliştirme Projesi** |  | 126.75d | 2010-11-01 | 2011-04-26 |  | 0d |  |  | 1560h |
| 2 | 1.1 | **Kapsam Tanimlama** |  | 5d | 2010-11-01 | 2010-11-05 |  | 0d |  |  | 40h |
| 3 | 1.1.1 | Proje kapsamının belirlenmesi |  | 2d | 2010-11-01 | 2010-11-02 |  | 0d | start no earlier than 2010-11-01 | Management | 16h |
| 4 | 1.1.2 | Proje sponsorlugunun üstlenilmesi |  | 1d | 2010-11-03 | 2010-11-03 | 3 | 0d |  | Management | 8h |
| 5 | 1.1.3 | Projede görev alacak öncelikli kaynakların belirlenmesi |  | 1d | 2010-11-04 | 2010-11-04 | 4 | 0d |  | Project Manager | 8h |
| 6 | 1.1.4 | Çekirdek ekibin oluşturulması |  | 1d | 2010-11-05 | 2010-11-05 | 5 | 0d |  | Project Manager | 8h |
| 7 | 1.1.5 | Kapsamın tamamlanması | milestone | 0d | 2010-11-05 | 2010-11-05 | 6 | 0d |  |  |  |
| 8 | 1.2 | **Analiz/Yazılım İhtiyaçları** |  | 14d | 2010-11-08 | 2010-11-25 |  | 0d |  |  | 120h |
| 9 | 1.2.1 | İhtiyaçların belrilenmesi |  | 5d | 2010-11-08 | 2010-11-12 | 7 | 0d |  | Analyst | 40h |
| 10 | 1.2.2 | Öngörülen yazılım özelliklerinin belirlenmesi |  | 3d | 2010-11-15 | 2010-11-17 | 9 | 0d |  | Analyst | 24h |
| 11 | 1.2.3 | Öngörülen bütçenin tanımlanması |  | 2d | 2010-11-18 | 2010-11-19 | 10 | 0d |  | Project Manager | 16h |
| 12 | 1.2.4 | Yazılım speklerinin ve bütçenin takım ile gözden geçirilmesi (Takımın görüşüne sunma) |  | 4h | 2010-11-22 | 2010-11-22 | 11 | 0d |  | Project Manager; Analyst | 8h |
| 13 | 1.2.5 | Yazılım spekleriyle ilgili geri dönüşlerin toplanması ve son haline kavuşturma |  | 2d | 2010-11-22 | 2010-11-24 | 12 | 0d |  | Analyst | 16h |
| 14 | 1.2.6 | Konsept, zaman ve bütçe açısından onayların alınması |  | 4h | 2010-11-24 | 2010-11-24 | 13 | 0d |  | Management; Project Manager | 8h |
| 15 | 1.2.7 | Gerekli kaynakların belirlenmesi |  | 1d | 2010-11-25 | 2010-11-25 | 14 | 0d |  | Project Manager | 8h |
| 16 | 1.2.8 | Analizin tamamlanması | milestone | 0d | 2010-11-25 | 2010-11-25 | 15 | 0d |  |  |  |
| 17 | 1.3 | **Tasarım** |  | 14d | 2010-11-26 | 2010-12-15 |  | 0d |  |  | 112h |
| 18 | 1.3.1 | Yazılım speklerinin gözden geçirilmesi |  | 2d | 2010-11-26 | 2010-11-29 | 16 | 0d |  | Analyst | 16h |
| 19 | 1.3.2 | Fonksiyonel speklerin geliştirilmesi |  | 5d | 2010-11-30 | 2010-12-06 | 18 | 0d |  | Analyst | 40h |
| 20 | 1.3.3 | Fonksiyonel speklerin prototip olarak oluşturulması |  | 4d | 2010-12-07 | 2010-12-10 | 19 | 0d |  | Analyst | 32h |
| 21 | 1.3.4 | Fonksiyonel speklerin gözden geçirilmesi |  | 2d | 2010-12-13 | 2010-12-14 | 20 | 0d |  | Management | 16h |
| 22 | 1.3.5 | Gerekli değişikliklerin yapılması |  | 1d | 2010-12-15 | 2010-12-15 | 21 | 0d |  | Management | 8h |
| 23 | 1.3.6 | Tasarımın tamamlanması | milestone | 0d | 2010-12-15 | 2010-12-15 | 22 | 0d |  |  |  |
| 24 | 1.4 | **Geliştirme** |  | 21.75d | 2010-12-16 | 2011-01-14 |  | 0d |  |  | 264h |
| 25 | 1.4.1 | Fonksiyonel speklerin gözden geçirilmesi |  | 1d | 2010-12-16 | 2010-12-16 | 23 | 0d |  | Developer | 8h |
| 26 | 1.4.2 | Modül parametrelerinin belirlenmesi |  | 1d | 2010-12-17 | 2010-12-17 | 25 | 0d |  | Developer | 8h |
| 27 | 1.4.3 | Geliştirme faaliyetine personel atama |  | 1d | 2010-12-20 | 2010-12-20 | 26 | 0d |  | Developer | 8h |
| 28 | 1.4.4 | Kod geliştirme |  | 15d | 2010-12-21 | 2011-01-10 | 27 | 0d |  | Developer | 120h |
| 29 | 1.4.5 | Geliştirmelerin testi |  | 15d | 2010-12-24 | 2011-01-14 | 28FS-7.5% | 0d |  | Developer | 120h |
| 30 | 1.4.6 | Geliştirme tamamlanması | milestone | 0d | 2011-01-14 | 2011-01-14 | 29 | 0d |  |  |  |

| ID | WBS | Task | Type | Duration | Start | Finish | Predecessors | Total slack | Free slack | Resources | Work |
| --- | --- | --- | --- | --- | --- | --- | --- | --- | --- | --- | --- |
| 31 | 1.5 | **Test** |  | 48.75d | 2010-12-16 | 2011-02-22 |  | 17.75d |  |  | 280h |
| 32 | 1.5.1 | Ürün speklerini kullanarak birim test planlarının geliştirilmesi |  | 4d | 2010-12-16 | 2010-12-21 | 23 | 17.75d | 0d | Testers | 32h |
| 33 | 1.5.2 | Ürün speklerini kullanarak entegrasyon test planlarının geliştirilmesi |  | 4d | 2010-12-16 | 2010-12-21 | 23 | 67.75d | 0d | Testers | 32h |
| 34 | 1.5.3 | **Birim Testi** |  | 15d | 2011-01-14 | 2011-02-04 |  | 0d |  |  | 120h |
| 35 | 1.5.3.1 | Modüler kodların gözden geçirilmesi |  | 5d | 2011-01-14 | 2011-01-21 | 32, 30 | 0d |  | Testers | 40h |
| 36 | 1.5.3.2 | Ürün spekleri için modül bileşkelerinin testi |  | 2d | 2011-01-21 | 2011-01-25 | 30, 35 | 0d |  | Testers | 16h |
| 37 | 1.5.3.3 | Yanlış kodalnmış ürün speklerinin belirlenmesi |  | 3d | 2011-01-25 | 2011-01-28 | 36 | 0d |  | Testers | 24h |
| 38 | 1.5.3.4 | Kodların düzeltilmesi |  | 3d | 2011-01-28 | 2011-02-02 | 37 | 0d |  | Testers | 24h |
| 39 | 1.5.3.5 | Düzeltilmiş kodların yeniden testi |  | 2d | 2011-02-02 | 2011-02-04 | 38 | 0d |  | Testers | 16h |
| 40 | 1.5.3.6 | Birim testlerin tamamlanması | milestone | 0d | 2011-02-04 | 2011-02-04 | 39 | 0d |  |  |  |
| 41 | 1.5.4 | **Entegrasyon Testi** |  | 12d | 2011-02-04 | 2011-02-22 |  | 0d |  |  | 96h |
| 42 | 1.5.4.1 | Modül entegrasyonu testi |  | 5d | 2011-02-04 | 2011-02-11 | 40 | 0d |  | Testers | 40h |
| 43 | 1.5.4.2 | Yanlış kodlanmış ürün speklerinin belirlenmesi |  | 2d | 2011-02-11 | 2011-02-15 | 42 | 0d |  | Testers | 16h |
| 44 | 1.5.4.3 | Kodların düzeltilmesi |  | 3d | 2011-02-15 | 2011-02-18 | 43 | 0d |  | Testers | 24h |
| 45 | 1.5.4.4 | Düzeltilmiş kodların yeniden testi |  | 2d | 2011-02-18 | 2011-02-22 | 44 | 0d |  | Testers | 16h |
| 46 | 1.5.4.5 | Entegrasyon testinin tamamlanması | milestone | 0d | 2011-02-22 | 2011-02-22 | 45 | 0d |  |  |  |
| 47 | 1.6 | **Eğitim** |  | 20d | 2011-02-22 | 2011-03-22 |  | 5d |  |  | 200h |
| 48 | 1.6.1 | Son kullanıcılar için eğitim speklerinin tanımlanması |  | 3d | 2011-02-22 | 2011-02-25 | 46 | 5d | 0d | Trainers | 24h |
| 49 | 1.6.2 | Helpdesk personeli için eğitim speklerinin geliştirilmesi |  | 3d | 2011-02-22 | 2011-02-25 | 46 | 5d | 0d | Trainers | 24h |
| 50 | 1.6.3 | Eğitim verme yöntemlerinin belirlenmesi (Bilgisayarlı sınıf, staj, seminer) |  | 2d | 2011-02-22 | 2011-02-24 | 46 | 21d | 16d | Trainers | 16h |
| 51 | 1.6.4 | Eğitim malzemelerinin hazırlanması |  | 3w | 2011-02-25 | 2011-03-18 | 48, 49 | 5d | 0d | Trainers | 120h |
| 52 | 1.6.5 | Kullanıcıların eğitime alınacağı tarihlerin belirlenmesi |  | 2d | 2011-03-18 | 2011-03-22 | 51, 50 | 5d | 0d | Trainers | 16h |
| 53 | 1.6.6 | Eğitim hazırlıklarının tamamlanması | milestone | 0d | 2011-03-22 | 2011-03-22 | 52 | 5d |  |  |  |
| 54 | 1.7 | **Dökümantasyon** |  | 25d | 2011-02-22 | 2011-03-29 |  | 0d |  |  | 336h |
| 55 | 1.7.1 | Yardım dökümanların niteliğinin belirlenmesi |  | 1d | 2011-02-22 | 2011-02-23 | 46 | 0d |  | Technical Communicators | 8h |
| 56 | 1.7.2 | Yardım sisteminin geliştirilmesi |  | 3w | 2011-02-23 | 2011-03-16 | 55 | 0d |  | Technical Communicators | 120h |
| 57 | 1.7.3 | Yardım dökümantasyonlarının gözden geçirilmesi |  | 3d | 2011-03-16 | 2011-03-21 | 56 | 0d |  | Technical Communicators | 24h |
| 58 | 1.7.4 | Yardım dökümanlarıyla ilgili geri beslemelerin toplanması |  | 2d | 2011-03-21 | 2011-03-23 | 57 | 0d |  | Technical Communicators | 16h |
| 59 | 1.7.5 | Kullanıcı manuel niteliklerinin tanımlanmasıi |  | 2d | 2011-02-22 | 2011-02-24 | 46 | 4d | 0d | Technical Communicators | 16h |
| 60 | 1.7.6 | Kullanıcı manuellerinin oluşturulması |  | 3w | 2011-02-24 | 2011-03-17 | 59 | 4d |  | Technical Communicators | 120h |
| 61 | 1.7.7 | Bütün dökümanların son gözden geçirilmesi için dağıtımı |  | 2d | 2011-03-23 | 2011-03-25 | 60, 58 | 0d |  | Technical Communicators | 16h |
| 62 | 1.7.8 | Kullanıcı dökümanlarıyla ilgili geri dönüşlerin toplanması |  | 2d | 2011-03-25 | 2011-03-29 | 61 | 0d |  | Technical Communicators | 16h |
| 63 | 1.7.9 | Dökümantasyon aşamasının tamamlanması | milestone | 0d | 2011-03-29 | 2011-03-29 | 62, 58 | 0d |  |  |  |

| ID | WBS | Task | Type | Duration | Start | Finish | Predecessors | Total slack | Free slack | Resources | Work |
| --- | --- | --- | --- | --- | --- | --- | --- | --- | --- | --- | --- |
| 64 | 1.8 | **Pilot Uygulama** |  | 81.75d | 2010-12-22 | 2011-04-14 |  | 0d |  |  | 144h |
| 65 | 1.8.1 | Test grubunun belirlenmesi |  | 1d | 2010-12-22 | 2010-12-22 | 32, 33 | 67.75d | 0d | Project Manager | 8h |
| 66 | 1.8.2 | Yazılım dağıtım mekanizmasının geliştirilmesi |  | 1d | 2010-12-23 | 2010-12-23 | 65 | 67.75d |  |  |  |
| 67 | 1.8.3 | Yazılımların yüklenmesi |  | 1d | 2011-03-29 | 2011-03-30 | 46, 66, 63, 53 | 0d |  | Deployment Team | 8h |
| 68 | 1.8.4 | Kullanıcı geri dönüşlerinin toplanması |  | 1w | 2011-03-30 | 2011-04-06 | 67 | 0d |  | Deployment Team | 40h |
| 69 | 1.8.5 | Testlerin değerlendirilmesi |  | 1d | 2011-04-06 | 2011-04-07 | 68 | 0d |  | Deployment Team | 8h |
| 70 | 1.8.6 | Gerekli değişikliklerin yapılması |  | 1w | 2011-04-07 | 2011-04-14 | 69 | 0d |  | Analyst; Testers | 80h |
| 71 | 1.8.7 | Pilot uygulamanın tamamlanması | milestone | 0d | 2011-04-14 | 2011-04-14 | 70 | 0d |  |  |  |
| 72 | 1.9 | **Yayma** |  | 5d | 2011-04-14 | 2011-04-21 |  | 0d |  |  | 40h |
| 73 | 1.9.1 | Yazılımın dağıtım stratejisinin tanımlanması |  | 1d | 2011-04-14 | 2011-04-15 | 71 | 0d |  | Deployment Team | 8h |
| 74 | 1.9.2 | Dağıtım metodolojisinin geliştirilmesi |  | 1d | 2011-04-15 | 2011-04-18 | 73 | 0d |  | Deployment Team | 8h |
| 75 | 1.9.3 | Dağıtım kaynaklarının güvenliğinin sağlanması |  | 1d | 2011-04-18 | 2011-04-19 | 74 | 0d |  | Deployment Team | 8h |
| 76 | 1.9.4 | Destek personelinin eğitimi |  | 1d | 2011-04-19 | 2011-04-20 | 75 | 0d |  | Deployment Team | 8h |
| 77 | 1.9.5 | Yazılımın dağıtımı |  | 1d | 2011-04-20 | 2011-04-21 | 76 | 0d |  | Deployment Team | 8h |
| 78 | 1.9.6 | Dağıtımın tamamlanması | milestone | 0d | 2011-04-21 | 2011-04-21 | 77 | 0d |  |  |  |
| 79 | 1.10 | **Post Implementation Review** |  | 3d | 2011-04-21 | 2011-04-26 |  | 0d |  |  | 24h |
| 80 | 1.10.1 | Alınan derslerin dökümantasyonu |  | 1d | 2011-04-21 | 2011-04-22 | 78 | 0d |  | Project Manager | 8h |
| 81 | 1.10.2 | Proje takımının dağıtılması |  | 1d | 2011-04-22 | 2011-04-25 | 80 | 0d |  | Project Manager | 8h |
| 82 | 1.10.3 | Yazılım bakım ekibinin kurulması |  | 1d | 2011-04-25 | 2011-04-26 | 81 | 0d |  | Project Manager | 8h |
| 83 | 1.11 | Yazılım geliştirme projesinin tamamlanması | milestone | 0d | 2011-04-26 | 2011-04-26 | 82 | 0d |  |  |  |
