# PLANLAMA GENEL SÜRECİ

Schedule from MS Project, 2010-11-01 to 2011-03-25, A marks actual dates.

## Calendars

- Standard: Mon-Fri 08:00-12:00, 13:00-17:00; Sat-Sun off.

## Schedule

| ID | Task | Duration | Start | Finish | Predecessors | Complete | Remaining | Total slack | Free slack | Constraint | Deadline |
| --- | --- | --- | --- | --- | --- | --- | --- | --- | --- | --- | --- |
| 1 | PLAN YAPILACAK ALANIN BELİRLENMESİ | 2d | 2010-11-01 | 2010-11-02 |  |  |  | 0d |  | start no earlier than 2010-11-01 | 2010-11-02 |
| 2 | ARAZİ ÇALIŞMASI PROGRAMININ VE ALTYAPISININ HAZIRLANMASI | 3d | 2010-11-03 | 2010-11-05 | 1 |  |  | 1d | 0d |  |  |
| 3 | İLGİLİ RESMİ KURUM GÖRÜŞLERİNİN TALEP EDİLMESİ | 3d | 2010-11-03 | 2010-11-05 | 1 |  |  | 15d |  |  |  |
| 4 | SAHA ÇALIŞMASI- VERİLERİN TOPLANMASI | 7d | 2010-11-08 | 2010-11-16 | 2 |  |  | 1d | 0d |  |  |
| 5 | VERİLERİN SİSTEME ENTEGRE EDİLMESİ | 8d | 2010-11-17 A | 2010-11-26 | 4 | 13% | 7d | 0d |  |  |  |
| 6 | ANALİZ VE SENTEZ ÇALIŞMASI | 12d | 2010-11-29 | 2010-12-14 | 5, 3 |  |  | 0d |  | start no earlier than 2010-11-16 |  |
| 7 | PLAN ÇALIŞMASI SENARYOLAR-ALTERNATİFLERİN ÜRETİLMESİ-KARAR AŞAMASI | 10d | 2010-12-15 | 2010-12-28 | 6 |  |  | 0d |  | start no earlier than 2010-11-29 |  |
| 8 | PLANIN ÇİZİLMESİ VE RAPORUN HAZIRLANMASI | 14d | 2010-12-29 | 2011-01-17 | 7 |  |  | 0d |  |  |  |
| 9 | PLANIN MECLİSE İLETİLMESİ | 5d | 2011-01-18 | 2011-01-24 | 8 |  |  | 0d |  |  |  |
| 10 | MECLİSTE KARAR ALMA SURECİ | 4d | 2011-01-25 | 2011-01-28 | 9 |  |  | 0d |  |  |  |
| 11 | MECLİS KARARININ VE PLANLARIN İMZALANMASI | 7d | 2011-01-31 | 2011-02-08 | 10 |  |  | 0d |  |  |  |
| 12 | PLANIN DAĞITIMI | 3d | 2011-02-09 | 2011-02-11 | 11 |  |  | 0d |  |  |  |
| 13 | ASKI SÜRECİ BİR AY | 30d | 2011-02-14 | 2011-03-25 | 12 |  |  | 0d |  |  |  |

Notes:
- 4: ANKET ÇALIªMASI / konut(%3-5 örnekleme) / iºyeri ( % 50 örnekleme) / sanayi birebir / BİNA TESPİTLERİ/ kat adedi / bina durumu / yapım cinsi / kat kullanımları/ fotoğraf çekimi
- 6: ANALİZ / arazi kullanım durumu / topoğrafya / hidroloji hidrografi (su bilimi) / jeolojik yapı/ taks , kaks, yoğunluk doku analizi / mülkiyet durumu / arazi değerleri / ulaºım / üst plan kararları / SENTEZ / yerleº,lebilir alanlar
