Schedule from MS Project, 2011-01-17 to 2011-03-23.
unv

## Calendars

- Standard: Mon-Fri 08:00-12:00, 13:00-17:00; Sat-Sun off.

## Schedule

| ID | WBS | Task | Duration | Start | Finish | Predecessors | Total slack | Free slack |
| --- | --- | --- | --- | --- | --- | --- | --- | --- |
| 1 | 1 | **Öztürk AVM İnşaatı** | 48d? | 2011-01-17 | 2011-03-23 |  | 0d |  |
| 2 | 1.1 | **Proje ve Resmi İşlemler** | 14d | 2011-01-17 | 2011-02-03 |  | 0d |  |
| 3 | 1.1.1 | Projelerin Hazırlanması | 5d | 2011-01-17 | 2011-01-21 |  | 0d |  |
| 4 | 1.1.2 | Projelerin Belediye Onayı | 7d | 2011-01-24 | 2011-02-01 | 3 | 0d |  |
| 5 | 1.1.3 | İnşaat Ruhsatı Alınması | 2d | 2011-02-02 | 2011-02-03 | 4 | 0d |  |
| 6 | 1.2 | **İnşaat İşleri** | 28d? | 2011-02-04 | 2011-03-15 |  | 0d |  |
| 7 | 1.2.1 | Fore kazık iksa yapılması | 20d | 2011-02-04 | 2011-03-03 | 5 | 0d |  |
| 8 | 1.2.2 | Hafriyat işleri | 4d | 2011-02-08 | 2011-02-11 | 7SS+2d | 0d |  |
| 9 | 1.2.3 | Grobeton yapılması | 1d | 2011-02-10 | 2011-02-10 | 8SS+2d | 0d |  |
| 10 | 1.2.4 | Temel ve taban yalıtımı | 4d | 2011-02-11 | 2011-02-16 | 9 | 0d |  |
| 11 | 1.2.5 | Membran Koruma betonu | 2d | 2011-02-14 | 2011-02-15 | 10SS+1d | 0d |  |
| 12 | 1.2.6 | Temel Demiri Bağlanması | 2d | 2011-02-15 | 2011-02-16 | 11SS+1d | 0d |  |
| 13 | 1.2.7 | Temel kalıbı yapılması | 1d? | 2011-02-17 | 2011-02-17 | 12 | 0d |  |
| 14 | 1.2.8 | Temel Betonu dökümü | 2d | 2011-02-18 | 2011-02-21 | 13 | 0d |  |
| 15 | 1.2.9 | Bodrum kolonları demiri | 2d | 2011-02-21 | 2011-02-22 | 14SS+1d | 0d |  |
| 16 | 1.2.10 | Bodrum kolonları kalıp | 2d | 2011-02-22 | 2011-02-23 | 15SS+1d | 0d |  |
| 17 | 1.2.11 | Bodrum kolonları betonu | 1d | 2011-02-23 | 2011-02-23 | 16SS+1d | 0d |  |
| 18 | 1.2.12 | Zemin kat döşemesi demiri | 3d | 2011-02-24 | 2011-02-28 | 17SS+1d | 0d |  |
| 19 | 1.2.13 | Zemin kat döşemesi kalıbı | 3d | 2011-02-28 | 2011-03-02 | 18SS+2d | 0d |  |
| 20 | 1.2.14 | Zemin kat döşemesi betonu | 2d | 2011-03-02 | 2011-03-04 | 19SS+2.5d | 0d |  |
| 21 | 1.2.15 | 1. kat kolon demiri | 2d | 2011-03-04 | 2011-03-07 | 20SS+1.5d | 0d |  |
| 22 | 1.2.16 | 1.kat kolon kalıbı | 2d | 2011-03-07 | 2011-03-08 | 21SS+1d | 6d | 0d |
| 23 | 1.2.17 | 1.kat kolon betonu dökümü | 1d | 2011-03-08 | 2011-03-09 | 22SS+1.5d | 6d | 0d |
| 24 | 1.2.18 | 1.kat döşemesi kalıp | 3d | 2011-03-09 | 2011-03-14 | 23SS+1d | 6d | 0d |
| 25 | 1.2.19 | 1.kat döşemesi demir | 3d | 2011-03-10 | 2011-03-15 | 24SS+1d | 6d | 0d |
| 26 | 1.2.20 | 1.kat döşemesi betonu | 1d | 2011-03-15 | 2011-03-15 | 25SS+2.5d | 6d |  |

| ID | WBS | Task | Duration | Start | Finish | Predecessors | Total slack |
| --- | --- | --- | --- | --- | --- | --- | --- |
| 27 | 1.3 | **Çevre düzenleme işleri** | 12d | 2011-03-08 | 2011-03-23 |  | 0d |
| 28 | 1.3.1 | Peyzaj çalışmaları | 12d | 2011-03-08 | 2011-03-23 | 21SS+2d | 0d |
