# İsmailavsar

Schedule from MS Project, 2011-01-17 to 2011-05-16, costs in TL.
unv

## Calendars

- Standard: Mon-Fri 08:00-12:00, 13:00-17:00; Sat-Sun off.

## Resources

| Resource | Cost per use |
| --- | --- |
| ofis personeli | 50 |
| düz işçi | 10 |
| kalıpçı ustası | 35 |
| demirci | 45 |
| yalıtımcı | 55 |
| fdgd |  |

## Schedule

| ID | WBS | Task | Duration | Start | Finish | Predecessors | Total slack | Resources | Work | Cost |
| --- | --- | --- | --- | --- | --- | --- | --- | --- | --- | --- |
| 1 | 1 | **Seyrantepe İstasyonu İnşaatı** | 86d | 2011-01-17 | 2011-05-16 |  | 0d |  | 440h | 450 |
| 2 | 1.1 | **Seyrantepe İstasyonu Proje çalışmaları** | 19d | 2011-01-17 | 2011-02-10 |  | 0d |  | 440h | 450 |
| 3 | 1.1.1 | Ön Proje Çalışması | 5d | 2011-01-17 | 2011-01-21 |  | 0d | ofis personeli [200%] | 80h | 100 |
| 4 | 1.1.2 | Kesin Projelerin Kabulü | 3d | 2011-01-24 | 2011-01-26 | 3 | 0d | ofis personeli | 24h | 50 |
| 5 | 1.1.3 | Uygulama Projelerinin Kesinleşmesi | 10d | 2011-01-27 | 2011-02-09 | 4 | 0d | ofis personeli [400%] | 320h | 200 |
| 6 | 1.1.4 | Proje çıktılarının hazırlanması | 1d | 2011-02-10 | 2011-02-10 | 5 | 0d | ofis personeli [200%] | 16h | 100 |
| 7 | 1.2 | **Seyrantepe İstasyonu İnşaat Çalşışmaları** | 67d | 2011-02-11 | 2011-05-16 |  | 0d |  |  |  |
| 8 | 1.2.1 | Fore Kazık İmalatı | 20d | 2011-02-11 | 2011-03-10 | 6 | 0d |  |  |  |
| 9 | 1.2.2 | Hafriyat | 22d | 2011-03-15 | 2011-04-13 | 8FS+2d | 0d |  |  |  |
| 10 | 1.2.3 | Ankraj Çalışması | 19d | 2011-03-17 | 2011-04-12 | 9SS+2d | 24d |  |  |  |
| 11 | 1.2.4 | Grobeton Serilmesi | 1d | 2011-04-14 | 2011-04-14 | 9 | 0d |  |  |  |
| 12 | 1.2.5 | Membran Çalışması | 2d | 2011-04-15 | 2011-04-18 | 11 | 0d |  |  |  |
| 13 | 1.2.6 | Koruma Betonu | 1d | 2011-04-18 | 2011-04-18 | 12SS+1d | 0d |  |  |  |
| 14 | 1.2.7 | Temel Demiri | 5d | 2011-04-19 | 2011-04-25 | 13 | 0d |  |  |  |
| 15 | 1.2.8 | Demel Kalıp | 5d | 2011-04-20 | 2011-04-26 | 14SS+1d | 0d |  |  |  |
| 16 | 1.2.9 | Beton Dökümü | 1d | 2011-04-27 | 2011-04-27 | 15 | 0d |  |  |  |
| 17 | 1.2.10 | Kolon Donatı | 3d | 2011-04-28 | 2011-05-02 | 16 | 0d |  |  |  |
| 18 | 1.2.11 | Kolon Kalıp | 2d | 2011-04-29 | 2011-05-02 | 17SS+1d | 0d |  |  |  |
| 19 | 1.2.12 | Kolon Beton | 1d | 2011-05-03 | 2011-05-03 | 18 | 0d |  |  |  |
| 20 | 1.2.13 | Döşeme Tabliyesi | 5d | 2011-05-05 | 2011-05-11 | 19FS+1d | 0d |  |  |  |
| 21 | 1.2.14 | Döşeme Donatısı | 4d | 2011-05-09 | 2011-05-12 | 20SS+2d | 0d |  |  |  |
| 22 | 1.2.15 | Döşeme Betonu | 2d | 2011-05-13 | 2011-05-16 | 21 | 0d |  |  |  |
